# Сопроводительный файл

Schedule from MS Project, 2002-01-10 to 2002-04-19, status date 2002-02-10.
MS Project 2002
Составление плана задач - 8. Добавляем повторяющиеся задачи.

## Calendars

- Standard: Mon-Thu 09:00-12:00, 13:00-18:00; Fri 08:00-12:00, 13:00-17:00; Sat-Sun off. Exceptions (off unless hours are given): 2002-02-25, 2002-03-08.

## Schedule

| ID | WBS | Task | Type | Duration | Start | Finish | Predecessors | Total slack | Free slack | Constraint |
| --- | --- | --- | --- | --- | --- | --- | --- | --- | --- | --- |
| 1 | 1 | **Планирование номера** |  | 69.12d | 2002-01-10 | 2002-04-19 |  | 0d |  |  |
| 2 | 1.A | Сбор предложений от авторов |  | 5d | 2002-01-10 | 2002-01-16 |  | 0d |  |  |
| 3 | 1.B | Подготовка плана номера |  | 3d | 2002-01-17 | 2002-01-21 | 2 | 0d |  |  |
| 4 | 1.C | Предварительная редколлегия |  | 1d | 2002-01-22 | 2002-01-22 | 3 | 0d |  |  |
| 5 | 1.D | Доработка планов с учетом замечаний |  | 3d | 2002-01-23 | 2002-01-25 | 4 | 0d |  |  |
| 6 | 1.E | Редколлегия |  | 1d | 2002-01-28 | 2002-01-28 | 5 | 0d |  |  |
| 7 | 1.F | План номера утвержден | milestone | 0d | 2002-01-28 | 2002-01-28 | 6 | 0d |  |  |
| 8 | 1.7 | **Редакционное собрание** |  | 53.12d | 2002-02-01 | 2002-04-19 |  | 0.88d |  |  |
| 9 | 1.7.1 | Редакционное собрание 1 |  | 1h | 2002-02-01 | 2002-02-01 |  | 53.88d |  | start no earlier than 2002-02-01 |
| 10 | 1.7.2 | Редакционное собрание 2 |  | 1h | 2002-02-08 | 2002-02-08 |  | 48.88d |  | start no earlier than 2002-02-08 |
| 11 | 1.7.3 | Редакционное собрание 3 |  | 1h | 2002-02-15 | 2002-02-15 |  | 43.88d |  | start no earlier than 2002-02-15 |
| 12 | 1.7.4 | Редакционное собрание 4 |  | 1h | 2002-02-22 | 2002-02-22 |  | 38.88d |  | start no earlier than 2002-02-22 |
| 13 | 1.7.5 | Редакционное собрание 5 |  | 1h | 2002-03-01 | 2002-03-01 |  | 34.88d |  | start no earlier than 2002-03-01 |
| 14 | 1.7.6 | Редакционное собрание 6 |  | 1h | 2002-03-11 | 2002-03-11 |  | 29.88d |  | start no earlier than 2002-03-08 |
| 15 | 1.7.7 | Редакционное собрание 7 |  | 1h | 2002-03-15 | 2002-03-15 |  | 25.88d |  | start no earlier than 2002-03-15 |
| 16 | 1.7.8 | Редакционное собрание 8 |  | 1h | 2002-03-22 | 2002-03-22 |  | 20.88d |  | start no earlier than 2002-03-22 |
| 17 | 1.7.9 | Редакционное собрание 9 |  | 1h | 2002-03-29 | 2002-03-29 |  | 15.88d |  | start no earlier than 2002-03-29 |
| 18 | 1.7.10 | Редакционное собрание 10 |  | 1h | 2002-04-05 | 2002-04-05 |  | 10.88d |  | start no earlier than 2002-04-05 |
| 19 | 1.7.11 | Редакционное собрание 11 |  | 1h | 2002-04-12 | 2002-04-12 |  | 5.88d |  | start no earlier than 2002-04-12 |
| 20 | 1.7.12 | Редакционное собрание 12 |  | 1h | 2002-04-19 | 2002-04-19 |  | 0.88d |  | start no earlier than 2002-04-19 |
| 21 | 2 | **Подготовка материалов** |  | 35d | 2002-01-29 | 2002-03-20 | 7 | 0d |  |  |
| 22 | 2.A | **Подготовка обложки** |  | 30d | 2002-02-01 | 2002-03-18 |  | 0d |  |  |
| 23 | 2.A-a | Отбор модели |  | 2d | 2002-02-01 | 2002-02-04 |  | 0d |  | must start on 2002-02-01 |
| 24 | 2.A-b | Фотосъемка модели |  | 4d | 2002-02-05 | 2002-02-08 | 23 | 28d | 21d |  |
| 25 | 2.A-c | Подготовка анонсов материалов номера для обложки |  | 3d | 2002-03-11 | 2002-03-13 | 35FS-5% | 7d | 0d |  |
| 26 | 2.A-d | Передача рекламных анонсов в предыдущий номер | milestone | 1d | 2002-03-11 | 2002-03-11 | 35FS-5% | 29d |  |  |
| 27 | 2.A-e | Верстка обложки |  | 3d | 2002-03-14 | 2002-03-18 | 25, 24 | 7d | 0d |  |
| 28 | 2.A-f | Обложка готова | milestone | 0d | 2002-03-18 | 2002-03-18 | 27 | 7d |  |  |

| ID | WBS | Task | Type | Duration | Start | Finish | Predecessors | Total slack | Free slack | Constraint |
| --- | --- | --- | --- | --- | --- | --- | --- | --- | --- | --- |
| 29 | 2.B | **Подготовка текстов** |  | 35d | 2002-01-29 | 2002-03-20 |  | 0d |  |  |
| 30 | 2.B-a | Подготовка редакционных заданий |  | 3d | 2002-01-29 | 2002-01-31 |  | 0d |  |  |
| 31 | 2.B-b | Рассылка заданий авторам |  | 2d | 2002-02-01 | 2002-02-04 | 30 | 0d |  |  |
| 32 | 2.B-c | Утверждение заданий |  | 4d | 2002-02-05 | 2002-02-08 | 31 | 0d |  |  |
| 33 | 2.B-d | Статьи в работе у авторов | milestone | 0d | 2002-02-08 | 2002-02-08 | 32 | 0d |  |  |
| 34 | 2.B-e | Статьи поступили в редакцию | milestone | 0d | 2002-02-22 | 2002-02-22 | 33FS+10d | 0d |  |  |
| 35 | 2.B-f | Редактирование материалов |  | 16d | 2002-02-26 | 2002-03-20 | 34 | 0d |  |  |
| 36 | 2.B-g | Техническое редактирование |  | 14d | 2002-02-28 | 2002-03-20 | 35SS+2d | 0d |  |  |
| 37 | 2.B-h | Тексты готовы | milestone | 0d | 2002-03-20 | 2002-03-20 | 36 | 22d |  |  |
| 38 | 2.C | Подготовка материалов завершена | milestone | 0d | 2002-03-20 | 2002-03-20 | 36 | 22d |  |  |
| 39 | 3 | **Верстка журнала** |  | 18d | 2002-03-05 | 2002-03-29 |  | 0d |  |  |
| 40 | 3.A | Обработка текста и иллюстраций |  | 14d | 2002-03-05 | 2002-03-25 | 36SS+3d | 0d |  |  |
| 41 | 3.B | Вычитка |  | 14d | 2002-03-11 | 2002-03-28 | 40SS+3d | 15d | 0d |  |
| 42 | 3.C | Сверка |  | 12d | 2002-03-14 | 2002-03-29 | 41SS+3d | 15d |  |  |
| 43 | 3.D | Подготовка оглавления |  | 2d | 2002-03-26 | 2002-03-27 | 40 | 0d |  |  |
| 44 | 3.E | Окончательная сборка |  | 2d | 2002-03-28 | 2002-03-29 | 43, 28 | 0d |  |  |
| 45 | 3.F | Номер сверстан | milestone | 0d | 2002-03-29 | 2002-03-29 | 44 | 0d |  |  |
| 46 | 4 | **Предпечатная подготовка** |  | 15d | 2002-04-01 | 2002-04-19 | 45 | 0d |  |  |
| 47 | 4.A | Конвертция сверстанного номера в формат Mac |  | 5d | 2002-04-01 | 2002-04-05 |  | 0d |  |  |
| 48 | 4.B | Цветоделение |  | 7d | 2002-04-08 | 2002-04-16 | 47 | 0d |  |  |
| 49 | 4.C | Коррекция |  | 7d | 2002-04-09 | 2002-04-17 | 48SS+1d | 0d |  |  |
| 50 | 4.D | Вывод пленок |  | 7d | 2002-04-11 | 2002-04-19 | 49SS+2d | 0d |  |  |
| 51 | 4.E | Номер готов к передаче в типографию | milestone | 0d | 2002-04-19 | 2002-04-19 | 50 | 0d |  | finish no later than 2002-04-20 |
