# Сопроводительный файл

Schedule from MS Project, 2001-10-22 to 2002-01-25, status date 2002-02-10.
MS Project 2002
Составление плана задач - 5. Определение длительностей задач и взаимосвязей между задачами.

## Calendars

- Standard: Mon-Thu 09:00-12:00, 13:00-18:00; Fri 08:00-12:00, 13:00-17:00; Sat-Sun off.

## Schedule

| ID | WBS | Task | Type | Duration | Start | Finish | Predecessors | Total slack | Free slack |
| --- | --- | --- | --- | --- | --- | --- | --- | --- | --- |
| 1 | 1 | **Планирование номера** |  | 13d | 2001-10-22 | 2001-11-07 |  | 0d |  |
| 2 | 1.1 | Сбор предложений от авторов |  | 5d | 2001-10-22 | 2001-10-26 |  | 0d |  |
| 3 | 1.2 | Подготовка плана номера |  | 3d | 2001-10-29 | 2001-10-31 | 2 | 0d |  |
| 4 | 1.3 | Предварительная редколлегия |  | 1d | 2001-11-01 | 2001-11-01 | 3 | 0d |  |
| 5 | 1.4 | Доработка планов с учетом замечаний |  | 3d | 2001-11-02 | 2001-11-06 | 4 | 0d |  |
| 6 | 1.5 | Редколлегия |  | 1d | 2001-11-07 | 2001-11-07 | 5 | 0d |  |
| 7 | 1.6 | План номера утвержден | milestone | 0d | 2001-11-07 | 2001-11-07 | 6 | 0d |  |
| 8 | 2 | **Подготовка материалов** |  | 37d | 2001-11-08 | 2001-12-28 | 7 | 0d |  |
| 9 | 2.1 | **Подготовка обложки** |  | 37d | 2001-11-08 | 2001-12-28 |  | 20d |  |
| 10 | 2.1.1 | Отбор модели |  | 5d | 2001-11-08 | 2001-11-14 |  | 48d | 0d |
| 11 | 2.1.2 | Фотосъемка модели |  | 4d | 2001-11-15 | 2001-11-20 | 10 | 48d |  |
| 12 | 2.1.3 | Подготовка анонсов материалов номера для обложки |  | 3d | 2001-12-21 | 2001-12-25 | 21FS-4d | 3d | 0d |
| 13 | 2.1.4 | Верстка обложки |  | 3d | 2001-12-26 | 2001-12-28 | 12 | 3d | 0d |
| 14 | 2.1.5 | Обложка готова | milestone | 0d | 2001-12-28 | 2001-12-28 | 13 | 3d |  |
| 15 | 2.2 | **Подготовка текстов** |  | 35d | 2001-11-08 | 2001-12-26 |  | 0d |  |
| 16 | 2.2.1 | Подготовка редакционных заданий |  | 3d | 2001-11-08 | 2001-11-12 |  | 0d |  |
| 17 | 2.2.2 | Рассылка заданий авторам |  | 2d | 2001-11-13 | 2001-11-14 | 16 | 0d |  |
| 18 | 2.2.3 | Утверждение заданий |  | 4d | 2001-11-15 | 2001-11-20 | 17 | 0d |  |
| 19 | 2.2.4 | Статьи в работе у авторов | milestone | 0d | 2001-11-20 | 2001-11-20 | 18 | 0d |  |
| 20 | 2.2.5 | Статьи поступили в редакцию | milestone | 0d | 2001-12-04 | 2001-12-04 | 19FS+10d | 0d |  |
| 21 | 2.2.6 | Редактирование материалов |  | 16d | 2001-12-05 | 2001-12-26 | 20 | 0d |  |
| 22 | 2.2.7 | Техническое редактирование |  | 14d | 2001-12-07 | 2001-12-26 | 21SS+2d | 0d |  |
| 23 | 2.2.8 | Тексты готовы | milestone | 0d | 2001-12-26 | 2001-12-26 | 22 | 22d |  |
| 24 | 2.3 | Подготовка материалов завершена | milestone | 0d | 2001-12-26 | 2001-12-26 | 22 | 22d |  |

| ID | WBS | Task | Type | Duration | Start | Finish | Predecessors | Total slack | Free slack |
| --- | --- | --- | --- | --- | --- | --- | --- | --- | --- |
| 25 | 3 | **Верстка журнала** |  | 18d | 2001-12-12 | 2002-01-04 |  | 0d |  |
| 26 | 3.1 | Обработка текста и иллюстраций |  | 14d | 2001-12-12 | 2001-12-31 | 22SS+3d | 0d |  |
| 27 | 3.2 | Вычитка |  | 14d | 2001-12-17 | 2002-01-03 | 26SS+3d | 15d | 0d |
| 28 | 3.3 | Сверка |  | 12d | 2001-12-20 | 2002-01-04 | 27SS+3d | 15d |  |
| 29 | 3.4 | Подготовка оглавления |  | 2d | 2002-01-01 | 2002-01-02 | 26 | 0d |  |
| 30 | 3.5 | Окончательная сборка |  | 2d | 2002-01-03 | 2002-01-04 | 29, 14 | 0d |  |
| 31 | 3.6 | Номер сверстан | milestone | 0d | 2002-01-04 | 2002-01-04 | 30 | 0d |  |
| 32 | 4 | **Предпечатная подготовка** |  | 15d | 2002-01-07 | 2002-01-25 | 31 | 0d |  |
| 33 | 4.1 | Конвертция сверстанного номера в формат Mac |  | 5d | 2002-01-07 | 2002-01-11 |  | 0d |  |
| 34 | 4.2 | Цветоделение |  | 7d | 2002-01-14 | 2002-01-22 | 33 | 0d |  |
| 35 | 4.3 | Коррекция |  | 7d | 2002-01-15 | 2002-01-23 | 34SS+1d | 0d |  |
| 36 | 4.4 | Вывод пленок |  | 7d | 2002-01-17 | 2002-01-25 | 35SS+2d | 0d |  |
| 37 | 4.5 | Номер готов к передаче в типографию | milestone | 0d | 2002-01-25 | 2002-01-25 | 36 | 0d |  |
