# Сопроводительный файл

Schedule from MS Project, 2002-01-10 to 2002-04-19, status date 2002-02-10.
MS Project 2002
Составление плана задач - 6. Изменяем дату старта проекта.

## Calendars

- Standard: Mon-Thu 09:00-12:00, 13:00-18:00; Fri 08:00-12:00, 13:00-17:00; Sat-Sun off. Exceptions (off unless hours are given): 2002-02-25, 2002-03-08.

## Schedule

| ID | WBS | Task | Type | Duration | Start | Finish | Predecessors | Total slack | Free slack |
| --- | --- | --- | --- | --- | --- | --- | --- | --- | --- |
| 1 | 1 | **Планирование номера** |  | 13d | 2002-01-10 | 2002-01-28 |  | 0d |  |
| 2 | 1.1 | Сбор предложений от авторов |  | 5d | 2002-01-10 | 2002-01-16 |  | 0d |  |
| 3 | 1.2 | Подготовка плана номера |  | 3d | 2002-01-17 | 2002-01-21 | 2 | 0d |  |
| 4 | 1.3 | Предварительная редколлегия |  | 1d | 2002-01-22 | 2002-01-22 | 3 | 0d |  |
| 5 | 1.4 | Доработка планов с учетом замечаний |  | 3d | 2002-01-23 | 2002-01-25 | 4 | 0d |  |
| 6 | 1.5 | Редколлегия |  | 1d | 2002-01-28 | 2002-01-28 | 5 | 0d |  |
| 7 | 1.6 | План номера утвержден | milestone | 0d | 2002-01-28 | 2002-01-28 | 6 | 0d |  |
| 8 | 2 | **Подготовка материалов** |  | 37d | 2002-01-29 | 2002-03-22 | 7 | 0d |  |
| 9 | 2.1 | **Подготовка обложки** |  | 37d | 2002-01-29 | 2002-03-22 |  | 20d |  |
| 10 | 2.1.1 | Отбор модели |  | 5d | 2002-01-29 | 2002-02-04 |  | 48d | 0d |
| 11 | 2.1.2 | Фотосъемка модели |  | 4d | 2002-02-05 | 2002-02-08 | 10 | 48d |  |
| 12 | 2.1.3 | Подготовка анонсов материалов номера для обложки |  | 3d | 2002-03-15 | 2002-03-19 | 21FS-4d | 3d | 0d |
| 13 | 2.1.4 | Верстка обложки |  | 3d | 2002-03-20 | 2002-03-22 | 12 | 3d | 0d |
| 14 | 2.1.5 | Обложка готова | milestone | 0d | 2002-03-22 | 2002-03-22 | 13 | 3d |  |
| 15 | 2.2 | **Подготовка текстов** |  | 35d | 2002-01-29 | 2002-03-20 |  | 0d |  |
| 16 | 2.2.1 | Подготовка редакционных заданий |  | 3d | 2002-01-29 | 2002-01-31 |  | 0d |  |
| 17 | 2.2.2 | Рассылка заданий авторам |  | 2d | 2002-02-01 | 2002-02-04 | 16 | 0d |  |
| 18 | 2.2.3 | Утверждение заданий |  | 4d | 2002-02-05 | 2002-02-08 | 17 | 0d |  |
| 19 | 2.2.4 | Статьи в работе у авторов | milestone | 0d | 2002-02-08 | 2002-02-08 | 18 | 0d |  |
| 20 | 2.2.5 | Статьи поступили в редакцию | milestone | 0d | 2002-02-22 | 2002-02-22 | 19FS+10d | 0d |  |
| 21 | 2.2.6 | Редактирование материалов |  | 16d | 2002-02-26 | 2002-03-20 | 20 | 0d |  |
| 22 | 2.2.7 | Техническое редактирование |  | 14d | 2002-02-28 | 2002-03-20 | 21SS+2d | 0d |  |
| 23 | 2.2.8 | Тексты готовы | milestone | 0d | 2002-03-20 | 2002-03-20 | 22 | 22d |  |
| 24 | 2.3 | Подготовка материалов завершена | milestone | 0d | 2002-03-20 | 2002-03-20 | 22 | 22d |  |

| ID | WBS | Task | Type | Duration | Start | Finish | Predecessors | Total slack | Free slack |
| --- | --- | --- | --- | --- | --- | --- | --- | --- | --- |
| 25 | 3 | **Верстка журнала** |  | 18d | 2002-03-05 | 2002-03-29 |  | 0d |  |
| 26 | 3.1 | Обработка текста и иллюстраций |  | 14d | 2002-03-05 | 2002-03-25 | 22SS+3d | 0d |  |
| 27 | 3.2 | Вычитка |  | 14d | 2002-03-11 | 2002-03-28 | 26SS+3d | 15d | 0d |
| 28 | 3.3 | Сверка |  | 12d | 2002-03-14 | 2002-03-29 | 27SS+3d | 15d |  |
| 29 | 3.4 | Подготовка оглавления |  | 2d | 2002-03-26 | 2002-03-27 | 26 | 0d |  |
| 30 | 3.5 | Окончательная сборка |  | 2d | 2002-03-28 | 2002-03-29 | 29, 14 | 0d |  |
| 31 | 3.6 | Номер сверстан | milestone | 0d | 2002-03-29 | 2002-03-29 | 30 | 0d |  |
| 32 | 4 | **Предпечатная подготовка** |  | 15d | 2002-04-01 | 2002-04-19 | 31 | 0d |  |
| 33 | 4.1 | Конвертция сверстанного номера в формат Mac |  | 5d | 2002-04-01 | 2002-04-05 |  | 0d |  |
| 34 | 4.2 | Цветоделение |  | 7d | 2002-04-08 | 2002-04-16 | 33 | 0d |  |
| 35 | 4.3 | Коррекция |  | 7d | 2002-04-09 | 2002-04-17 | 34SS+1d | 0d |  |
| 36 | 4.4 | Вывод пленок |  | 7d | 2002-04-11 | 2002-04-19 | 35SS+2d | 0d |  |
| 37 | 4.5 | Номер готов к передаче в типографию | milestone | 0d | 2002-04-19 | 2002-04-19 | 36 | 0d |  |
