# Издание номера журнала

Schedule from MS Project, 2002-01-10 to 2002-05-14, status date 2002-02-10, costs in $.
MS Project 2002
Настройка диаграммы Гантта, при которой задачи с ограничениями выделены особым цветом на диаграмме.

## Calendars

- Standard: Mon-Thu 09:00-12:00, 13:00-18:00; Fri 08:00-12:00, 13:00-17:00; Sat-Sun off. Exceptions (off unless hours are given): 2002-02-25, 2002-03-08.

## Resources

| Resource | Group | Rate | Cost per use |
| --- | --- | --- | --- |
| Иванов | Редактор раздела | 6.25 |  |
| Бумага для типографии |  | 15 |  |
| Фотомодель | Фотомодель |  | 200 |
| Терехов | Оператор печатного аппарата | 2.5 |  |
| Тарарухин | Оператор печатного аппарата | 3.44 |  |
| Борисов | Оператор печатного аппарата | 3.12 |  |
| Семенов | Оператор Mac | 4.69 |  |
| Бурков | Оператор Mac | 3.12 |  |
| Лимонов | Оператор Mac | 5 |  |
| Улендеева | Верстальщик | 4.69 |  |
| Сергеева | Верстальщик | 3.75 |  |
| Жуков | Фотограф | 3.12 |  |
| Еремин | Дизайнер | 7.5 |  |
| Ураганов | Корректор | 500 |  |
| Баранов | Корректор | 500 |  |
| Козлов | Технический редактор | 800 |  |
| Васин | Технический редактор | 800 |  |
| Уваров | Главный редактор | 2000 |  |
| Галкина | Отвественный секретарь | 3.12 |  |
| Сидоров | Редактор раздела | 6.25 |  |
| Петров | Редактор раздела | 6.25 |  |
| Краска для вывода пленок |  | 100 |  |
| Фотопленка |  | 2 |  |
| Тарасова | Верстальщик | 3.75 |  |
| Авторы |  | 0.25 | 1000 |

## Schedule

| ID | WBS | Task | Type | Duration | Start | Finish | Predecessors | Total slack | Free slack | Constraint | Resources | Work | Cost | Text4 | Text2 | Text3 |
| --- | --- | --- | --- | --- | --- | --- | --- | --- | --- | --- | --- | --- | --- | --- | --- | --- |
| 1 | МАЙ//001 | **Планирование номера** |  | 17d | 2002-01-10 | 2002-02-01 |  | -1d | 0d |  |  | 76.81h | 511.3 |  |  |  |
| 2 | МАЙ//001.A | Сбор предложений от авторов |  | 5d | 2002-01-10 | 2002-01-16 |  | -1d | 0d |  | Иванов [25%]; Петров [25%]; Сидоров [25%] | 15h | 93.75 | НД |  |  |
| 3 | МАЙ//001.B | Подготовка плана номера |  | 3d | 2002-01-17 | 2002-01-21 | 2 | -1d | 0d |  | Иванов [25%]; Петров [25%]; Сидоров [25%]; Уваров [12.5%] | 20h | 137.5 | НД |  |  |
| 4 | МАЙ//001.C | Предварительная редколлегия |  | 3h | 2002-01-22 | 2002-01-22 | 3 | -1d | 0d |  | Иванов; Петров; Сидоров; Галкина; Уваров | 15h | 103.12 | НД |  |  |
| 5 | МАЙ//001.D | Доработка планов с учетом замечаний |  | 3d | 2002-01-22 | 2002-01-25 | 4 | -1d | 0d |  | Иванов; Петров; Сидоров | 17.81h | 111.32 | НД |  |  |
| 6 | МАЙ//001.E | Редколлегия |  | 3h | 2002-01-24 | 2002-01-25 | 5FS-5h | -1d | 0d |  | Иванов; Петров; Сидоров; Галкина; Уваров | 9h | 65.61 | НД |  |  |
| 7 | МАЙ//001.F | План номера утвержден |  | 6d | 2002-01-25 | 2002-02-01 | 6FS-1h | -1d | 0d | start no earlier than 2002-01-07 |  |  |  | Пнд 07.01.02 |  |  |
| 8 | МАЙ//002 | **Подготовка материалов** |  | 46.13d | 2002-02-01 | 2002-04-10 | 7 | 0d |  |  |  | 379.54h | 54,037.82 |  |  |  |
| 9 | МАЙ//002.A | **Подготовка обложки** |  | 46.13d | 2002-02-01 | 2002-04-10 |  | 0d |  |  |  | 88.27h | 543.3 |  |  |  |
| 10 | МАЙ//002.A-a | Отбор модели |  | 13.83h | 2002-02-01 | 2002-02-04 |  | -1d | 0d | must start on 2002-02-01 | Еремин [50%] | 6.92h | 51.87 | Птн 01.02.02 |  |  |
| 11 | МАЙ//002.A-b | Фотосъемка модели |  | 3d | 2002-02-04 | 2002-02-07 | 10 | 45.27d | 38.4d |  | Жуков; Фотомодель; Фотопленка | 48h | 277 | НД | Срыв сроков из-за использования неопытного сотрудника. | Высокая |
| 12 | МАЙ//002.A-c | Подготовка анонсов материалов номера для обложки |  | 3d | 2002-04-02 | 2002-04-05 | 23FS-5% | 6.87d | 0d | start no earlier than 2002-03-12 | Сидоров [49%] | 11.75h | 73.43 | Втр 12.03.02 |  |  |
| 13 | МАЙ//002.A-d | Передача рекламных анонсов в предыдущий номер | milestone | 1d | 2002-04-02 | 2002-04-03 | 23FS-5% | 29.5d |  |  |  |  |  | НД |  |  |
| 14 | МАЙ//002.A-e | Верстка обложки |  | 3d | 2002-04-05 | 2002-04-10 | 12, 11 | 6.87d | 0d |  | Еремин [70%]; Жуков [20%] | 21.6h | 141 | НД | Срыв сроков из-за использования неопытного сотрудника. | Средняя |
| 15 | МАЙ//002.A-f | Обложка готова | milestone | 0d | 2002-04-10 | 2002-04-10 | 14 | 6.87d | 6.79d |  |  |  |  | НД |  |  |
| 16 | МАЙ//002.B | **Подготовка текстов** |  | 29.13d | 2002-02-26 | 2002-04-09 |  | 6.87d |  |  |  | 291.27h | 53,494.52 |  |  |  |
| 17 | МАЙ//002.B-a | Подготовка редакционных заданий |  | 3.42d | 2002-02-26 | 2002-03-01 |  | 6.87d | 0d | start no earlier than 2002-02-25 | Иванов; Петров; Сидоров; Галкина | 73.09h | 405.78 | Пнд 25.02.02 |  |  |
| 18 | МАЙ//002.B-b | Рассылка заданий авторам |  | 1.34d | 2002-03-01 | 2002-03-05 | 17 | 6.87d | 0d |  | Галкина [33.3%] | 1.96h | 6.12 | НД |  |  |
| 19 | МАЙ//002.B-c | Утверждение заданий авторами |  | 4d | 2002-03-05 | 2002-03-12 | 18 | 6.87d | 0d |  | Галкина [12.5%] | 4h | 12.5 | НД |  |  |
| 20 | МАЙ//002.B-d | Статьи в работе у авторов | milestone | 0d | 2002-03-12 | 2002-03-12 | 19 | 6.87d | 0d |  |  |  |  | НД |  |  |
| 21 | 2.2.5 | Проверка состояния статей |  | 1d | 2002-03-19 | 2002-03-20 | 20FS+5d | 39.5d |  |  | Иванов [20%]; Петров [20%]; Сидоров [20%]; Галкина [25%] | 6.8h | 36.25 | НД |  |  |
| 22 | МАЙ//002.B-e | Статьи поступили в редакцию | milestone | 0d | 2002-03-26 | 2002-03-26 | 20FS+10d | 6.87d | 0d |  | Авторы |  | 1,000 | НД | Авторы сдадут статьи позже нужного. | Высокая |
| 23 | 002.B-f | **Редактирование материалов** |  | 10d | 2002-03-26 | 2002-04-09 | 22 | 6.87d | 0d |  |  | 78.9h | 493.11 |  |  |  |
| 24 | 2.2.7.1 | Редактирование раздела 1 |  | 10d | 2002-03-26 | 2002-04-09 |  | 6.87d |  |  | Иванов [62.5%] | 26.3h | 164.37 | НД |  |  |
| 25 | 2.2.7.2 | Редактирование раздела 2 |  | 10d | 2002-03-26 | 2002-04-09 |  | 6.87d |  |  | Петров [62.5%] | 26.3h | 164.37 | НД |  |  |
| 26 | 2.2.7.3 | Редактирование раздела 3 |  | 10d | 2002-03-26 | 2002-04-09 |  | 6.87d |  |  | Сидоров [62.5%] | 26.3h | 164.37 | НД |  |  |

Notes:
- 2: Text1: Файл предложений в редакционном формате.
- 3: Text1: План номера в формате XLS с названиями статей от редакторов разделов.
- 4: Text1: Предварительный план номиера обсужден.
- 5: Text1: Планы каждого из редакторов разделов доработаны с учетом замечаний.
- 6: Задания на этот номер должны включать темы: / ·летний отдых; / ·фотокамеры; / ·видеокамеры. / Text1: Окончательный план номера согласован с редакторами разделов и главным редактором.
- 13: Шаблон документа для передачи анонсов.
- 17: Подготовить задания нужно за 3 дня!
- 19: Авторы должны уложиться в 2 дня!
- 23: Сокращено до 12 дней.

| ID | WBS | Task | Type | Duration | Start | Finish | Predecessors | Total slack | Free slack | Constraint | Resources | Work | Cost | Text4 | Text2 | Text3 |
| --- | --- | --- | --- | --- | --- | --- | --- | --- | --- | --- | --- | --- | --- | --- | --- | --- |
| 27 | МАЙ//002.B-g | **Техническое редактирование** |  | 4d | 2002-03-28 | 2002-04-03 | 23SS+2d | 29.5d | 0d |  | Галкина [50%]; Васин; Козлов | 126.53h | 51,540.76 |  |  |  |
| 28 | 2.2.8.1 | Редактирование раздела 1 |  | 4d | 2002-03-28 | 2002-04-03 |  | 29.5d | 0d |  | Иванов [62.5%] | 15.51h | 96.92 | НД |  |  |
| 29 | 2.2.8.2 | Редактирование раздела 2 |  | 4d | 2002-03-28 | 2002-04-03 |  | 29.5d | 0d |  | Петров [62.5%] | 15.51h | 96.92 | НД |  |  |
| 30 | 2.2.8.3 | Редактирование раздела 3 |  | 4d | 2002-03-28 | 2002-04-03 |  | 29.5d | 0d |  | Сидоров [62.5%] | 15.51h | 96.92 | НД |  |  |
| 31 | МАЙ//002.B-h | Тексты готовы | milestone | 0d | 2002-04-03 | 2002-04-03 | 28, 29, 30 | 29.5d |  |  |  |  |  | НД |  |  |
| 32 | МАЙ//002.C | Подготовка материалов завершена | milestone | 0d | 2002-04-03 | 2002-04-03 | 27 | 29.5d |  |  |  |  |  | НД |  |  |
| 33 | МАЙ//003 | **Верстка журнала** |  | 14.79d | 2002-04-02 | 2002-04-22 |  | 0.08d |  |  |  | 353h | 42,966.25 |  |  |  |
| 34 | МАЙ//003.A | Обработка текста и иллюстраций |  | 10.17d | 2002-04-02 | 2002-04-16 | 27SS+3d | 0.08d | 0d |  | Тарасова [98.4%]; Улендеева [98.4%] | 160h | 675 | НД | Срыв сроков из-за использования неопытного сотрудника. | Средняя |
| 35 | МАЙ//003.B | **Вычитка** |  | 5d | 2002-04-05 | 2002-04-12 | 34SS+3d | 22.5d | 0d |  |  | 80h | 40,000 |  |  |  |
| 36 | 3.2.1 | Вычитка1 |  | 5d | 2002-04-05 | 2002-04-12 |  | 22.5d |  |  | Ураганов | 40h | 20,000 | НД |  |  |
| 37 | 3.2.2 | Вычитка1 |  | 5d | 2002-04-05 | 2002-04-12 |  | 22.5d |  |  | Баранов | 40h | 20,000 | НД |  |  |
| 38 | МАЙ//003.C | **Сверка** |  | 5d | 2002-04-10 | 2002-04-17 | 35SS+3d | 3.87d | 3.79d |  |  | 100h | 625 |  |  |  |
| 39 | 3.3.1 | Сверка1 |  | 5d | 2002-04-10 | 2002-04-17 |  | 3.87d |  |  | Иванов | 40h | 250 | НД |  |  |
| 40 | 3.3.2 | Сверка2 |  | 5d | 2002-04-10 | 2002-04-17 |  | 3.87d |  |  | Петров | 40h | 250 | НД |  |  |
| 41 | 3.3.3 | Сверка3 |  | 4d | 2002-04-10 | 2002-04-16 |  | 4.87d |  | start no earlier than 2002-03-13 | Сидоров | 20h | 125 | Срд 13.03.02 |  |  |
| 42 | МАЙ//003.D | Подготовка оглавления |  | 16h | 2002-04-16 | 2002-04-18 | 34 | 0.08d | 0d | finish no earlier than 2002-03-20 | Сидоров [50%] | 5h | 31.25 | Срд 20.03.02 |  |  |
| 43 | МАЙ//003.E | Окончательная сборка |  | 2d | 2002-04-18 | 2002-04-22 | 42, 15 | 0.08d | 0d |  | Сидоров [25%]; Васин [25%] | 6h | 1,625 | НД |  |  |
| 44 | МАЙ//003.F | Номер сверстан | milestone | 0d | 2002-04-22 | 2002-04-22 | 43, 38 | 0.08d | 0d |  |  |  |  | НД |  |  |
| 45 | 3.7 | Оформить предварительный заказ материалов для типографии |  | 2h | 2002-04-17 | 2002-04-17 | 44FS-3d | 18.38d |  |  | Лимонов | 2h | 10 | НД |  |  |
| 46 | МАЙ//004 | **Предпечатная подготовка** |  | 15.63d | 2002-04-22 | 2002-05-14 | 44 | 0d |  |  |  | 325.14h | 1,319.3 |  |  |  |
| 47 | МАЙ//004.A | Конвертция сверстанного номера в формат Mac |  | 6.25d | 2002-04-22 | 2002-04-26 |  | 0d |  |  | Лимонов [76.9%]; Бурков [98.8%]; Семенов [76.9%] | 85.84h | 357.74 | НД |  |  |
| 48 | МАЙ//004.B | Цветоделение |  | 11.67d | 2002-04-26 | 2002-05-07 | 47 | 0d |  |  | Бурков [20%]; Семенов [20%]; Борисов [25%]; Тарарухин [20%]; Терехов [20%]; Бумага для типографии | 57.4h | 208.02 | НД |  |  |
| 49 | МАЙ//004.C | Коррекция |  | 6.92d | 2002-04-29 | 2002-05-03 | 48SS+1d | 0d |  |  | Лимонов [25%]; Бурков [25%]; Семенов [25%] | 41.5h | 177.22 | НД |  |  |
| 50 | МАЙ//004.D | Вывод пленок |  | 15.25d | 2002-05-01 | 2002-05-14 | 49SS+2d | 0d |  |  | Лимонов [34.8%]; Бурков [34.8%]; Борисов [41.8%]; Тарарухин [41.8%]; Терехов [41.8%]; Краска для вывода пленок | 140.4h | 576.32 | НД |  |  |
| 51 | МАЙ//004.E | Номер готов к передаче в типографию | milestone | 0d | 2002-05-14 | 2002-05-14 | 50 | 0d |  |  |  |  |  | НД |  |  |
